# LovelyLacePlanWphases

Schedule from MS Project, 2013-04-18 to 2013-07-23.

## Calendars

- Standard: Mon-Fri 08:00-12:00, 13:00-17:00; Sat-Sun off.

## Schedule

| ID | WBS | Task | Type | Duration | Start | Finish | Predecessors | Total slack |
| --- | --- | --- | --- | --- | --- | --- | --- | --- |
| 1 | 1 | **Pre-Project Phase** |  | 6d | 2013-04-18 | 2013-04-25 |  | 0d |
| 2 | 1.1 | Client Needs Meeting |  | 1d | 2013-04-18 | 2013-04-18 |  | 0d |
| 3 | 1.2 | Create Scope Statement |  | 3d | 2013-04-19 | 2013-04-23 | 2 | 0d |
| 4 | 1.3 | Create the list of team assests |  | 2d | 2013-04-24 | 2013-04-25 | 3 | 0d |
| 5 | 2 | **Design Production** |  | 31d | 2013-04-26 | 2013-06-07 |  | 0d |
| 6 | 2.1 | Design Research |  | 3d | 2013-04-26 | 2013-04-30 | 4 | 0d |
| 7 | 2.2 | Create a set of design Mockups |  | 2w | 2013-05-01 | 2013-05-14 | 6 | 0d |
| 8 | 2.3 | Start Client Iteration Process |  | 3w | 2013-05-15 | 2013-06-04 | 7 | 0d |
| 9 | 2.4 | Slice the design |  | 3d | 2013-06-05 | 2013-06-07 | 8 | 0d |
| 10 | 3 | **Functionality Production** |  | 21d | 2013-06-10 | 2013-07-08 |  | 0d |
| 11 | 3.1 | Functionality Research |  | 3d | 2013-06-10 | 2013-06-12 | 9 | 0d |
| 12 | 3.2 | Build the Data Map |  | 2d | 2013-06-13 | 2013-06-14 | 11 | 0d |
| 13 | 3.3 | Send the data map to database Developer for Database creation |  | 2w | 2013-06-17 | 2013-06-28 | 12 | 0d |
| 14 | 3.4 | Send Data Map and expectations to .net programmers |  | 1d | 2013-07-01 | 2013-07-01 | 13 | 0d |
| 15 | 3.5 | Combine the layout and functionality |  | 1w | 2013-07-02 | 2013-07-08 | 14 | 0d |
| 16 | 4 | **Host Environment** |  | 11d | 2013-07-09 | 2013-07-23 |  | 0d |
| 17 | 4.1 | Research the host environment |  | 1d | 2013-07-09 | 2013-07-09 | 15 | 0d |
| 18 | 4.2 | Establish the host environment |  | 2d | 2013-07-10 | 2013-07-11 | 17 | 0d |
| 19 | 4.3 | Upload and test the site |  | 2d | 2013-07-12 | 2013-07-15 | 18 | 0d |
| 20 | 4.4 | Confirm Functionality with client |  | 1d | 2013-07-16 | 2013-07-16 | 19 | 0d |
| 21 | 4.5 | Alter any issues |  | 1w | 2013-07-17 | 2013-07-23 | 20 | 0d |
| 22 | 5 | Go Live! | milestone | 0d | 2013-07-23 | 2013-07-23 | 21 | 0d |
